# tutorial 1

Schedule from MS Project, 2010-06-29 to 2011-05-06.
FKA

## Calendars

- Standard: Mon-Fri 08:00-12:00, 13:00-17:00; Sat-Sun off.

## Resources

| Resource |
| --- |
| labour |
| manager |
| concrete |
| mobile crane |

## Schedule

| ID | WBS | Task | Duration | Start | Finish | Predecessors | Total slack | Free slack | Resources | Work |
| --- | --- | --- | --- | --- | --- | --- | --- | --- | --- | --- |
| 1 | 1 | **tutorial 1** | 224d | 2010-06-29 | 2011-05-06 |  | 0d |  |  | 8336h |
| 2 | 1.1 | footgrid A | 24d | 2010-06-29 | 2010-07-30 |  | 8d | 0d | labour; manager; concrete | 384h |
| 3 | 1.2 | basement | 94d | 2010-06-29 | 2010-11-05 |  | 0d |  | labour; manager; concrete | 1504h |
| 4 | 1.3 | manufacture | 130d | 2010-06-29 | 2010-12-27 |  | 26d |  | labour; manager; concrete | 2080h |
| 5 | 1.4 | footgridB | 32d | 2010-08-02 | 2010-09-14 | 2 | 8d | 0d | labour; manager; concrete | 512h |
| 6 | 1.5 | columnA 0 | 15d | 2010-08-02 | 2010-08-20 | 2 | 27d | 17d | labour; manager; concrete | 240h |
| 7 | 1.6 | footgridC | 20d | 2010-09-15 | 2010-10-12 | 5 | 8d | 0d | labour; manager; concrete | 320h |
| 8 | 1.7 | columnB 0 | 18d | 2010-09-15 | 2010-10-08 | 5, 6 | 10d | 2d | labour; manager; concrete | 288h |
| 9 | 1.8 | columnC 0 | 12d | 2010-10-13 | 2010-10-28 | 7, 8 | 8d | 6d | labour; manager; concrete | 192h |
| 10 | 1.9 | galfloor | 30d | 2010-10-13 | 2010-11-23 | 7, 8 | 12d |  | labour; concrete | 240h |
| 11 | 1.10 | hall office floor | 42d | 2010-11-08 | 2011-01-04 | 3, 9 | 2d |  | labour; concrete | 336h |
| 12 | 1.11 | hall access floor | 24d | 2010-11-08 | 2010-12-09 | 3, 8, 7 | 0d |  | labour; concrete | 192h |
| 13 | 1.12 | columnB 4 | 20d | 2010-12-10 | 2011-01-06 | 10, 12 | 0d |  | labour; manager; concrete | 320h |
| 14 | 1.13 | columnC 4 | 18d | 2011-01-07 | 2011-02-01 | 11, 13 | 0d |  | labour; manager; concrete | 288h |
| 15 | 1.14 | erectpre | 14d | 2011-02-02 | 2011-02-21 | 14, 4 | 0d |  | labour; manager; concrete; mobile crane | 224h |
| 16 | 1.15 | columnB 8 | 18d | 2011-02-22 | 2011-03-17 | 15 | 0d |  | labour; manager; concrete | 288h |
| 17 | 1.16 | columnA 8 | 22d | 2011-02-02 | 2011-03-03 | 14, 4 | 10d |  | labour; manager; concrete | 352h |
| 18 | 1.17 | galleryhouse | 36d | 2011-03-18 | 2011-05-06 | 17, 16 | 0d |  | labour; manager | 576h |
